# Estructura edificio

Schedule from MS Project, 2023-02-13 to 2023-10-20.

## Calendars

- Estándar: Mon-Fri 09:00-13:00, 15:00-19:00; Sat-Sun off.

## Schedule

| ID | WBS | Task | Duration | Start | Finish | Predecessors | Total slack | Free slack | Rdto. Minorado | Med. Ejec. | Planif. | Real | EDT y Nombre |
| --- | --- | --- | --- | --- | --- | --- | --- | --- | --- | --- | --- | --- | --- |
| 1 | 1 | **Zona 1** | 134d | 2023-02-13 | 2023-08-17 |  | 0d |  | 0 /día | 0 | 13/02/2023 - 13/02/2023 1d. | Sin Comenzar | 1 Zona 1 |
| 2 | 1.1 | zapatas y vigas de cimentación Z1 | 15d | 2023-02-13 | 2023-03-03 |  | 0d |  | 0 /día | 0 | 13/02/2023 - 03/03/2023 15d. | Sin Comenzar | 1.1 zapatas y vigas de cimentación Z1 |
| 3 | 1.2 | pilares arranque y muros ascensores Z1 | 3d | 2023-03-06 | 2023-03-08 | 2 | 45d | 0d | 0 /día | 0 | 06/03/2023 - 08/03/2023 3d. | Sin Comenzar | 1.2 pilares arranque y muros ascensores Z1 |
| 4 | 1.3 | forjado planta baja Z1 | 12d | 2023-03-09 | 2023-03-24 | 3 | 45d | 0d | 0 /día | 0 | 09/03/2023 - 24/03/2023 12d. | Sin Comenzar | 1.3 forjado planta baja Z1 |
| 5 | 1.4 | pilares y muros ascensor pb Z1 | 2d | 2023-03-27 | 2023-03-28 | 4 | 45d | 0d | 0 /día | 0 | 27/03/2023 - 28/03/2023 2d. | Sin Comenzar | 1.4 pilares y muros ascensor pb Z1 |
| 6 | 1.5 | forjado y escalera p1 Z1 | 12d | 2023-03-29 | 2023-04-13 | 5 | 45d | 0d | 0 /día | 0 | 29/03/2023 - 13/04/2023 12d. | Sin Comenzar | 1.5 forjado y escalera p1 Z1 |
| 7 | 1.6 | pilares y muros p1 Z1 | 2d | 2023-04-14 | 2023-04-17 | 6 | 45d | 0d | 0 /día | 0 | 14/04/2023 - 17/04/2023 2d. | Sin Comenzar | 1.6 pilares y muros p1 Z1 |
| 8 | 1.7 | forjado y escalera p2 Z1 | 12d | 2023-04-18 | 2023-05-03 | 7 | 45d | 0d | 0 /día | 0 | 18/04/2023 - 03/05/2023 12d. | Sin Comenzar | 1.7 forjado y escalera p2 Z1 |
| 9 | 1.8 | pilares y muros p2 Z1 | 2d | 2023-05-04 | 2023-05-05 | 8 | 45d | 0d | 0 /día | 0 | 04/05/2023 - 05/05/2023 2d. | Sin Comenzar | 1.8 pilares y muros p2 Z1 |
| 10 | 1.9 | forjado y escalera p3 Z1 | 12d | 2023-05-08 | 2023-05-23 | 9 | 45d | 0d | 0 /día | 0 | 08/05/2023 - 23/05/2023 12d. | Sin Comenzar | 1.9 forjado y escalera p3 Z1 |
| 11 | 1.10 | pilares y muros p3 Z1 | 2d | 2023-05-24 | 2023-05-25 | 10 | 45d | 0d | 0 /día | 0 | 24/05/2023 - 25/05/2023 2d. | Sin Comenzar | 1.10 pilares y muros p3 Z1 |
| 12 | 1.11 | forjado y escalera p4 Z1 | 12d | 2023-05-26 | 2023-06-12 | 11 | 45d | 0d | 0 /día | 0 | 26/05/2023 - 12/06/2023 12d. | Sin Comenzar | 1.11 forjado y escalera p4 Z1 |
| 13 | 1.12 | pilares y muros p4 Z1 | 2d | 2023-06-13 | 2023-06-14 | 12 | 45d | 0d | 0 /día | 0 | 13/06/2023 - 14/06/2023 2d. | Sin Comenzar | 1.12 pilares y muros p4 Z1 |
| 14 | 1.13 | forjado y escalera p5 Z1 | 12d | 2023-06-15 | 2023-06-30 | 13 | 45d | 0d | 0 /día | 0 | 15/06/2023 - 30/06/2023 12d. | Sin Comenzar | 1.13 forjado y escalera p5 Z1 |
| 15 | 1.14 | pilares y muros p5 Z1 | 2d | 2023-07-03 | 2023-07-04 | 14 | 45d | 0d | 0 /día | 0 | 03/07/2023 - 04/07/2023 2d. | Sin Comenzar | 1.14 pilares y muros p5 Z1 |
| 16 | 1.15 | forjado y escalera p6 Z1 | 12d | 2023-07-05 | 2023-07-20 | 15 | 45d | 0d | 0 /día | 0 | 05/07/2023 - 20/07/2023 12d. | Sin Comenzar | 1.15 forjado y escalera p6 Z1 |
| 17 | 1.16 | pilares y muros p6 Z1 | 2d | 2023-07-21 | 2023-07-24 | 16 | 45d | 0d | 0 /día | 0 | 21/07/2023 - 24/07/2023 2d. | Sin Comenzar | 1.16 pilares y muros p6 Z1 |
| 18 | 1.17 | forjado cubierta y escalera Z1 | 12d | 2023-07-25 | 2023-08-09 | 17 | 45d | 0d | 0 /día | 0 | 25/07/2023 - 09/08/2023 12d. | Sin Comenzar | 1.17 forjado cubierta y escalera Z1 |
| 19 | 1.18 | pilares y muros cubierta Z1 | 1d | 2023-08-10 | 2023-08-10 | 18 | 45d | 0d | 0 /día | 0 | 10/08/2023 - 10/08/2023 1d. | Sin Comenzar | 1.18 pilares y muros cubierta Z1 |
| 20 | 1.19 | forjado caseton Z1 | 5d | 2023-08-11 | 2023-08-17 | 19 | 45d | 0d | 0 /día | 0 | 11/08/2023 - 17/08/2023 5d. | Sin Comenzar | 1.19 forjado caseton Z1 |
| 21 | 2 | **Zona 2** | 134d | 2023-03-06 | 2023-09-07 |  | 0d |  | 0 /día | 0 | 13/02/2023 - 13/02/2023 1d. | Sin Comenzar | 2 Zona 2 |
| 22 | 2.1 | zapatas y vigas de cimentación Z2 | 15d | 2023-03-06 | 2023-03-24 | 2 | 0d |  | 0 /día | 0 | 06/03/2023 - 24/03/2023 15d. | Sin Comenzar | 2.1 zapatas y vigas de cimentación Z2 |
| 23 | 2.2 | pilares arranque y muros ascensores Z2 | 3d | 2023-03-27 | 2023-03-29 | 22 | 30d | 0d | 0 /día | 0 | 27/03/2023 - 29/03/2023 3d. | Sin Comenzar | 2.2 pilares arranque y muros ascensores Z2 |
| 24 | 2.3 | forjado planta baja Z2 | 12d | 2023-03-30 | 2023-04-14 | 23 | 30d | 0d | 0 /día | 0 | 30/03/2023 - 14/04/2023 12d. | Sin Comenzar | 2.3 forjado planta baja Z2 |
| 25 | 2.4 | pilares y muros ascensor pb Z2 | 2d | 2023-04-17 | 2023-04-18 | 24 | 30d | 0d | 0 /día | 0 | 17/04/2023 - 18/04/2023 2d. | Sin Comenzar | 2.4 pilares y muros ascensor pb Z2 |
| 26 | 2.5 | forjado y escalera p1 Z2 | 12d | 2023-04-19 | 2023-05-04 | 25 | 30d | 0d | 0 /día | 0 | 19/04/2023 - 04/05/2023 12d. | Sin Comenzar | 2.5 forjado y escalera p1 Z2 |
| 27 | 2.6 | pilares y muros p1 Z2 | 2d | 2023-05-05 | 2023-05-08 | 26 | 30d | 0d | 0 /día | 0 | 05/05/2023 - 08/05/2023 2d. | Sin Comenzar | 2.6 pilares y muros p1 Z2 |
| 28 | 2.7 | forjado y escalera p2 Z2 | 12d | 2023-05-09 | 2023-05-24 | 27 | 30d | 0d | 0 /día | 0 | 09/05/2023 - 24/05/2023 12d. | Sin Comenzar | 2.7 forjado y escalera p2 Z2 |
| 29 | 2.8 | pilares y muros p2 Z2 | 2d | 2023-05-25 | 2023-05-26 | 28 | 30d | 0d | 0 /día | 0 | 25/05/2023 - 26/05/2023 2d. | Sin Comenzar | 2.8 pilares y muros p2 Z2 |
| 30 | 2.9 | forjado y escalera p3 Z2 | 12d | 2023-05-29 | 2023-06-13 | 29 | 30d | 0d | 0 /día | 0 | 29/05/2023 - 13/06/2023 12d. | Sin Comenzar | 2.9 forjado y escalera p3 Z2 |
| 31 | 2.10 | pilares y muros p3 Z2 | 2d | 2023-06-14 | 2023-06-15 | 30 | 30d | 0d | 0 /día | 0 | 14/06/2023 - 15/06/2023 2d. | Sin Comenzar | 2.10 pilares y muros p3 Z2 |
| 32 | 2.11 | forjado y escalera p4 Z2 | 12d | 2023-06-16 | 2023-07-03 | 31 | 30d | 0d | 0 /día | 0 | 16/06/2023 - 03/07/2023 12d. | Sin Comenzar | 2.11 forjado y escalera p4 Z2 |
| 33 | 2.12 | pilares y muros p4 Z2 | 2d | 2023-07-04 | 2023-07-05 | 32 | 30d | 0d | 0 /día | 0 | 04/07/2023 - 05/07/2023 2d. | Sin Comenzar | 2.12 pilares y muros p4 Z2 |
| 34 | 2.13 | forjado y escalera p5 Z2 | 12d | 2023-07-06 | 2023-07-21 | 33 | 30d | 0d | 0 /día | 0 | 06/07/2023 - 21/07/2023 12d. | Sin Comenzar | 2.13 forjado y escalera p5 Z2 |
| 35 | 2.14 | pilares y muros p5 Z2 | 2d | 2023-07-24 | 2023-07-25 | 34 | 30d | 0d | 0 /día | 0 | 24/07/2023 - 25/07/2023 2d. | Sin Comenzar | 2.14 pilares y muros p5 Z2 |
| 36 | 2.15 | forjado y escalera p6 Z2 | 12d | 2023-07-26 | 2023-08-10 | 35 | 30d | 0d | 0 /día | 0 | 26/07/2023 - 10/08/2023 12d. | Sin Comenzar | 2.15 forjado y escalera p6 Z2 |
| 37 | 2.16 | pilares y muros p6 Z2 | 2d | 2023-08-11 | 2023-08-14 | 36 | 30d | 0d | 0 /día | 0 | 11/08/2023 - 14/08/2023 2d. | Sin Comenzar | 2.16 pilares y muros p6 Z2 |
| 38 | 2.17 | forjado cubierta y escalera Z2 | 12d | 2023-08-15 | 2023-08-30 | 37 | 30d | 0d | 0 /día | 0 | 15/08/2023 - 30/08/2023 12d. | Sin Comenzar | 2.17 forjado cubierta y escalera Z2 |
| 39 | 2.18 | pilares y muros cubierta Z2 | 1d | 2023-08-31 | 2023-08-31 | 38 | 30d | 0d | 0 /día | 0 | 31/08/2023 - 31/08/2023 1d. | Sin Comenzar | 2.18 pilares y muros cubierta Z2 |
| 40 | 2.19 | forjado caseton Z2 | 5d | 2023-09-01 | 2023-09-07 | 39 | 30d | 0d | 0 /día | 0 | 01/09/2023 - 07/09/2023 5d. | Sin Comenzar | 2.19 forjado caseton Z2 |

| ID | WBS | Task | Duration | Start | Finish | Predecessors | Total slack | Free slack | Rdto. Minorado | Med. Ejec. | Planif. | Real | EDT y Nombre |
| --- | --- | --- | --- | --- | --- | --- | --- | --- | --- | --- | --- | --- | --- |
| 41 | 3 | **Zona 3** | 134d | 2023-03-27 | 2023-09-28 |  | 0d |  | 0 /día | 0 | 13/02/2023 - 13/02/2023 1d. | Sin Comenzar | 3 Zona 3 |
| 42 | 3.1 | zapatas y vigas de cimentación Z3 | 15d | 2023-03-27 | 2023-04-14 | 22 | 0d |  | 0 /día | 0 | 27/03/2023 - 14/04/2023 15d. | Sin Comenzar | 3.1 zapatas y vigas de cimentación Z3 |
| 43 | 3.2 | pilares arranque y muros ascensores Z3 | 3d | 2023-04-17 | 2023-04-19 | 42 | 15d | 0d | 0 /día | 0 | 17/04/2023 - 19/04/2023 3d. | Sin Comenzar | 3.2 pilares arranque y muros ascensores Z3 |
| 44 | 3.3 | forjado planta baja Z3 | 12d | 2023-04-20 | 2023-05-05 | 43 | 15d | 0d | 0 /día | 0 | 20/04/2023 - 05/05/2023 12d. | Sin Comenzar | 3.3 forjado planta baja Z3 |
| 45 | 3.4 | pilares y muros ascensor pb Z3 | 2d | 2023-05-08 | 2023-05-09 | 44 | 15d | 0d | 0 /día | 0 | 08/05/2023 - 09/05/2023 2d. | Sin Comenzar | 3.4 pilares y muros ascensor pb Z3 |
| 46 | 3.5 | forjado y escalera p1 Z3 | 12d | 2023-05-10 | 2023-05-25 | 45 | 15d | 0d | 0 /día | 0 | 10/05/2023 - 25/05/2023 12d. | Sin Comenzar | 3.5 forjado y escalera p1 Z3 |
| 47 | 3.6 | pilares y muros p1 Z3 | 2d | 2023-05-26 | 2023-05-29 | 46 | 15d | 0d | 0 /día | 0 | 26/05/2023 - 29/05/2023 2d. | Sin Comenzar | 3.6 pilares y muros p1 Z3 |
| 48 | 3.7 | forjado y escalera p2 Z3 | 12d | 2023-05-30 | 2023-06-14 | 47 | 15d | 0d | 0 /día | 0 | 30/05/2023 - 14/06/2023 12d. | Sin Comenzar | 3.7 forjado y escalera p2 Z3 |
| 49 | 3.8 | pilares y muros p2 Z3 | 2d | 2023-06-15 | 2023-06-16 | 48 | 15d | 0d | 0 /día | 0 | 15/06/2023 - 16/06/2023 2d. | Sin Comenzar | 3.8 pilares y muros p2 Z3 |
| 50 | 3.9 | forjado y escalera p3 Z3 | 12d | 2023-06-19 | 2023-07-04 | 49 | 15d | 0d | 0 /día | 0 | 19/06/2023 - 04/07/2023 12d. | Sin Comenzar | 3.9 forjado y escalera p3 Z3 |
| 51 | 3.10 | pilares y muros p3 Z3 | 2d | 2023-07-05 | 2023-07-06 | 50 | 15d | 0d | 0 /día | 0 | 05/07/2023 - 06/07/2023 2d. | Sin Comenzar | 3.10 pilares y muros p3 Z3 |
| 52 | 3.11 | forjado y escalera p4 Z3 | 12d | 2023-07-07 | 2023-07-24 | 51 | 15d | 0d | 0 /día | 0 | 07/07/2023 - 24/07/2023 12d. | Sin Comenzar | 3.11 forjado y escalera p4 Z3 |
| 53 | 3.12 | pilares y muros p4 Z3 | 2d | 2023-07-25 | 2023-07-26 | 52 | 15d | 0d | 0 /día | 0 | 25/07/2023 - 26/07/2023 2d. | Sin Comenzar | 3.12 pilares y muros p4 Z3 |
| 54 | 3.13 | forjado y escalera p5 Z3 | 12d | 2023-07-27 | 2023-08-11 | 53 | 15d | 0d | 0 /día | 0 | 27/07/2023 - 11/08/2023 12d. | Sin Comenzar | 3.13 forjado y escalera p5 Z3 |
| 55 | 3.14 | pilares y muros p5 Z3 | 2d | 2023-08-14 | 2023-08-15 | 54 | 15d | 0d | 0 /día | 0 | 14/08/2023 - 15/08/2023 2d. | Sin Comenzar | 3.14 pilares y muros p5 Z3 |
| 56 | 3.15 | forjado y escalera p6 Z3 | 12d | 2023-08-16 | 2023-08-31 | 55 | 15d | 0d | 0 /día | 0 | 16/08/2023 - 31/08/2023 12d. | Sin Comenzar | 3.15 forjado y escalera p6 Z3 |
| 57 | 3.16 | pilares y muros p6 Z3 | 2d | 2023-09-01 | 2023-09-04 | 56 | 15d | 0d | 0 /día | 0 | 01/09/2023 - 04/09/2023 2d. | Sin Comenzar | 3.16 pilares y muros p6 Z3 |
| 58 | 3.17 | forjado cubierta y escalera Z3 | 12d | 2023-09-05 | 2023-09-20 | 57 | 15d | 0d | 0 /día | 0 | 05/09/2023 - 20/09/2023 12d. | Sin Comenzar | 3.17 forjado cubierta y escalera Z3 |
| 59 | 3.18 | pilares y muros cubierta Z3 | 1d | 2023-09-21 | 2023-09-21 | 58 | 15d | 0d | 0 /día | 0 | 21/09/2023 - 21/09/2023 1d. | Sin Comenzar | 3.18 pilares y muros cubierta Z3 |
| 60 | 3.19 | forjado caseton Z3 | 5d | 2023-09-22 | 2023-09-28 | 59 | 15d | 0d | 0 /día | 0 | 22/09/2023 - 28/09/2023 5d. | Sin Comenzar | 3.19 forjado caseton Z3 |
| 61 | 4 | **Zona 4** | 134d | 2023-04-17 | 2023-10-19 |  | 0d |  | 0 /día | 0 | 13/02/2023 - 13/02/2023 1d. | Sin Comenzar | 4 Zona 4 |
| 62 | 4.1 | zapatas y vigas de cimentación Z4 | 15d | 2023-04-17 | 2023-05-05 | 42 | 0d |  | 0 /día | 0 | 17/04/2023 - 05/05/2023 15d. | Sin Comenzar | 4.1 zapatas y vigas de cimentación Z4 |
| 63 | 4.2 | pilares arranque y muros ascensores Z4 | 3d | 2023-05-08 | 2023-05-10 | 62 | 0d |  | 0 /día | 0 | 08/05/2023 - 10/05/2023 3d. | Sin Comenzar | 4.2 pilares arranque y muros ascensores Z4 |
| 64 | 4.3 | forjado planta baja Z4 | 12d | 2023-05-11 | 2023-05-26 | 63 | 0d |  | 0 /día | 0 | 11/05/2023 - 26/05/2023 12d. | Sin Comenzar | 4.3 forjado planta baja Z4 |
| 65 | 4.4 | pilares y muros ascensor pb Z4 | 2d | 2023-05-29 | 2023-05-30 | 64 | 0d |  | 0 /día | 0 | 29/05/2023 - 30/05/2023 2d. | Sin Comenzar | 4.4 pilares y muros ascensor pb Z4 |
| 66 | 4.5 | forjado y escalera p1 Z4 | 12d | 2023-05-31 | 2023-06-15 | 65 | 0d |  | 0 /día | 0 | 31/05/2023 - 15/06/2023 12d. | Sin Comenzar | 4.5 forjado y escalera p1 Z4 |
| 67 | 4.6 | pilares y muros p1 Z4 | 2d | 2023-06-16 | 2023-06-19 | 66 | 0d |  | 0 /día | 0 | 16/06/2023 - 19/06/2023 2d. | Sin Comenzar | 4.6 pilares y muros p1 Z4 |
| 68 | 4.7 | forjado y escalera p2 Z4 | 12d | 2023-06-20 | 2023-07-05 | 67 | 0d |  | 0 /día | 0 | 20/06/2023 - 05/07/2023 12d. | Sin Comenzar | 4.7 forjado y escalera p2 Z4 |
| 69 | 4.8 | pilares y muros p2 Z4 | 2d | 2023-07-06 | 2023-07-07 | 68 | 0d |  | 0 /día | 0 | 06/07/2023 - 07/07/2023 2d. | Sin Comenzar | 4.8 pilares y muros p2 Z4 |
| 70 | 4.9 | forjado y escalera p3 Z4 | 12d | 2023-07-10 | 2023-07-25 | 69 | 0d |  | 0 /día | 0 | 10/07/2023 - 25/07/2023 12d. | Sin Comenzar | 4.9 forjado y escalera p3 Z4 |
| 71 | 4.10 | pilares y muros p3 Z4 | 2d | 2023-07-26 | 2023-07-27 | 70 | 0d |  | 0 /día | 0 | 26/07/2023 - 27/07/2023 2d. | Sin Comenzar | 4.10 pilares y muros p3 Z4 |
| 72 | 4.11 | forjado y escalera p4 Z4 | 12d | 2023-07-28 | 2023-08-14 | 71 | 0d |  | 0 /día | 0 | 28/07/2023 - 14/08/2023 12d. | Sin Comenzar | 4.11 forjado y escalera p4 Z4 |
| 73 | 4.12 | pilares y muros p4 Z4 | 2d | 2023-08-15 | 2023-08-16 | 72 | 0d |  | 0 /día | 0 | 15/08/2023 - 16/08/2023 2d. | Sin Comenzar | 4.12 pilares y muros p4 Z4 |
| 74 | 4.13 | forjado y escalera p5 Z4 | 12d | 2023-08-17 | 2023-09-01 | 73 | 0d |  | 0 /día | 0 | 17/08/2023 - 01/09/2023 12d. | Sin Comenzar | 4.13 forjado y escalera p5 Z4 |
| 75 | 4.14 | pilares y muros p5 Z4 | 2d | 2023-09-04 | 2023-09-05 | 74 | 0d |  | 0 /día | 0 | 04/09/2023 - 05/09/2023 2d. | Sin Comenzar | 4.14 pilares y muros p5 Z4 |
| 76 | 4.15 | forjado y escalera p6 Z4 | 12d | 2023-09-06 | 2023-09-21 | 75 | 0d |  | 0 /día | 0 | 06/09/2023 - 21/09/2023 12d. | Sin Comenzar | 4.15 forjado y escalera p6 Z4 |
| 77 | 4.16 | pilares y muros p6 Z4 | 2d | 2023-09-22 | 2023-09-25 | 76 | 0d |  | 0 /día | 0 | 22/09/2023 - 25/09/2023 2d. | Sin Comenzar | 4.16 pilares y muros p6 Z4 |
| 78 | 4.17 | forjado cubierta y escalera Z4 | 12d | 2023-09-26 | 2023-10-11 | 77 | 0d |  | 0 /día | 0 | 26/09/2023 - 11/10/2023 12d. | Sin Comenzar | 4.17 forjado cubierta y escalera Z4 |
| 79 | 4.18 | pilares y muros cubierta Z4 | 1d | 2023-10-12 | 2023-10-12 | 78 | 0d |  | 0 /día | 0 | 12/10/2023 - 12/10/2023 1d. | Sin Comenzar | 4.18 pilares y muros cubierta Z4 |
| 80 | 4.19 | forjado caseton Z4 | 5d | 2023-10-13 | 2023-10-19 | 79 | 0d |  | 0 /día | 0 | 13/10/2023 - 19/10/2023 5d. | Sin Comenzar | 4.19 forjado caseton Z4 |

| ID | WBS | Task | Duration | Start | Finish | Predecessors | Total slack | Free slack | Rdto. Minorado | Med. Ejec. | Planif. | Real | EDT y Nombre |
| --- | --- | --- | --- | --- | --- | --- | --- | --- | --- | --- | --- | --- | --- |
| 81 | 5 | **Seguridad zona 1** | 105d | 2023-03-27 | 2023-08-18 |  | 45d |  | 0 /día | 0 | 13/02/2023 - 13/02/2023 1d. | Sin Comenzar | 5 Seguridad zona 1 |
| 82 | 5.1 | barandillas planta baja Z1 | 1d | 2023-03-27 | 2023-03-27 | 4 | 149d |  | 0 /día | 0 | 27/03/2023 - 27/03/2023 1d. | Sin Comenzar | 5.1 barandillas planta baja Z1 |
| 83 | 5.2 | barandillas p1 Z1 | 1d | 2023-04-14 | 2023-04-14 | 6 | 135d |  | 0 /día | 0 | 14/04/2023 - 14/04/2023 1d. | Sin Comenzar | 5.2 barandillas p1 Z1 |
| 84 | 5.3 | barandillas p2 Z1 | 1d | 2023-05-04 | 2023-05-04 | 8 | 121d |  | 0 /día | 0 | 04/05/2023 - 04/05/2023 1d. | Sin Comenzar | 5.3 barandillas p2 Z1 |
| 85 | 5.4 | barandillas p3 Z1 | 1d | 2023-05-24 | 2023-05-24 | 10 | 107d |  | 0 /día | 0 | 24/05/2023 - 24/05/2023 1d. | Sin Comenzar | 5.4 barandillas p3 Z1 |
| 86 | 5.5 | barandillas p4 Z1 | 1d | 2023-06-13 | 2023-06-13 | 12 | 93d |  | 0 /día | 0 | 13/06/2023 - 13/06/2023 1d. | Sin Comenzar | 5.5 barandillas p4 Z1 |
| 87 | 5.6 | barandillas p5 Z1 | 1d | 2023-07-03 | 2023-07-03 | 14 | 79d |  | 0 /día | 0 | 03/07/2023 - 03/07/2023 1d. | Sin Comenzar | 5.6 barandillas p5 Z1 |
| 88 | 5.7 | barandillas p6 Z1 | 1d | 2023-07-21 | 2023-07-21 | 16 | 65d |  | 0 /día | 0 | 21/07/2023 - 21/07/2023 1d. | Sin Comenzar | 5.7 barandillas p6 Z1 |
| 89 | 5.8 | barandillas cubierta Z1 | 1d | 2023-08-10 | 2023-08-10 | 18 | 51d |  | 0 /día | 0 | 10/08/2023 - 10/08/2023 1d. | Sin Comenzar | 5.8 barandillas cubierta Z1 |
| 90 | 5.9 | barandillas caseton Z1 | 1d | 2023-08-18 | 2023-08-18 | 20 | 45d |  | 0 /día | 0 | 18/08/2023 - 18/08/2023 1d. | Sin Comenzar | 5.9 barandillas caseton Z1 |
| 91 | 5.10 | redes p1 Z1 | 15d | 2023-03-29 | 2023-04-18 | 6SS | 133d |  | 0 /día | 0 | 29/03/2023 - 18/04/2023 15d. | Sin Comenzar | 5.10 redes p1 Z1 |
| 92 | 5.11 | redes p2 Z1 | 15d | 2023-04-18 | 2023-05-08 | 8SS | 119d |  | 0 /día | 0 | 18/04/2023 - 08/05/2023 15d. | Sin Comenzar | 5.11 redes p2 Z1 |
| 93 | 5.12 | redes p3 Z1 | 15d | 2023-05-08 | 2023-05-26 | 10SS | 105d |  | 0 /día | 0 | 08/05/2023 - 26/05/2023 15d. | Sin Comenzar | 5.12 redes p3 Z1 |
| 94 | 5.13 | redes p4 Z1 | 15d | 2023-05-26 | 2023-06-15 | 12SS | 91d |  | 0 /día | 0 | 26/05/2023 - 15/06/2023 15d. | Sin Comenzar | 5.13 redes p4 Z1 |
| 95 | 5.14 | redes p5 Z1 | 15d | 2023-06-15 | 2023-07-05 | 14SS | 77d |  | 0 /día | 0 | 15/06/2023 - 05/07/2023 15d. | Sin Comenzar | 5.14 redes p5 Z1 |
| 96 | 5.15 | redes p6 Z1 | 15d | 2023-07-05 | 2023-07-25 | 16SS | 63d |  | 0 /día | 0 | 05/07/2023 - 25/07/2023 15d. | Sin Comenzar | 5.15 redes p6 Z1 |
| 97 | 5.16 | redes cubierta Z1 | 18d | 2023-07-25 | 2023-08-17 | 18SS | 46d | 0d | 0 /día | 0 | 25/07/2023 - 17/08/2023 18d. | Sin Comenzar | 5.16 redes cubierta Z1 |
| 98 | 5.17 | redes caseton Z1 | 6d | 2023-08-10 | 2023-08-17 | 97FF | 46d |  | 0 /día | 0 | 10/08/2023 - 17/08/2023 6d. | Sin Comenzar | 5.17 redes caseton Z1 |
| 99 | 6 | **Seguridad zona 2** | 105d | 2023-04-17 | 2023-09-08 |  | 30d |  |  |  |  |  | 6 Seguridad zona 2 |
| 100 | 6.1 | barandillas planta baja Z2 | 1d | 2023-04-17 | 2023-04-17 | 24 | 134d |  | 0 /día | 0 | 17/04/2023 - 17/04/2023 1d. | Sin Comenzar | 6.1 barandillas planta baja Z2 |
| 101 | 6.2 | barandillas p1 Z2 | 1d | 2023-05-05 | 2023-05-05 | 26 | 120d |  | 0 /día | 0 | 05/05/2023 - 05/05/2023 1d. | Sin Comenzar | 6.2 barandillas p1 Z2 |
| 102 | 6.3 | barandillas p2 Z2 | 1d | 2023-05-25 | 2023-05-25 | 28 | 106d |  | 0 /día | 0 | 25/05/2023 - 25/05/2023 1d. | Sin Comenzar | 6.3 barandillas p2 Z2 |
| 103 | 6.4 | barandillas p3 Z2 | 1d | 2023-06-14 | 2023-06-14 | 30 | 92d |  | 0 /día | 0 | 14/06/2023 - 14/06/2023 1d. | Sin Comenzar | 6.4 barandillas p3 Z2 |
| 104 | 6.5 | barandillas p4 Z2 | 1d | 2023-07-04 | 2023-07-04 | 32 | 78d |  | 0 /día | 0 | 04/07/2023 - 04/07/2023 1d. | Sin Comenzar | 6.5 barandillas p4 Z2 |
| 105 | 6.6 | barandillas p5 Z2 | 1d | 2023-07-24 | 2023-07-24 | 34 | 64d |  | 0 /día | 0 | 24/07/2023 - 24/07/2023 1d. | Sin Comenzar | 6.6 barandillas p5 Z2 |
| 106 | 6.7 | barandillas p6 Z2 | 1d | 2023-08-11 | 2023-08-11 | 36 | 50d |  | 0 /día | 0 | 11/08/2023 - 11/08/2023 1d. | Sin Comenzar | 6.7 barandillas p6 Z2 |
| 107 | 6.8 | barandillas cubierta Z2 | 1d | 2023-08-31 | 2023-08-31 | 38 | 36d |  | 0 /día | 0 | 31/08/2023 - 31/08/2023 1d. | Sin Comenzar | 6.8 barandillas cubierta Z2 |
| 108 | 6.9 | barandillas caseton Z2 | 1d | 2023-09-08 | 2023-09-08 | 40 | 30d |  | 0 /día | 0 | 08/09/2023 - 08/09/2023 1d. | Sin Comenzar | 6.9 barandillas caseton Z2 |
| 109 | 6.10 | redes p1 Z2 | 15d | 2023-04-19 | 2023-05-09 | 26SS | 118d |  | 0 /día | 0 | 19/04/2023 - 09/05/2023 15d. | Sin Comenzar | 6.10 redes p1 Z2 |
| 110 | 6.11 | redes p2 Z2 | 15d | 2023-05-09 | 2023-05-29 | 28SS | 104d |  | 0 /día | 0 | 09/05/2023 - 29/05/2023 15d. | Sin Comenzar | 6.11 redes p2 Z2 |
| 111 | 6.12 | redes p3 Z2 | 15d | 2023-05-29 | 2023-06-16 | 30SS | 90d |  | 0 /día | 0 | 29/05/2023 - 16/06/2023 15d. | Sin Comenzar | 6.12 redes p3 Z2 |
| 112 | 6.13 | redes p4 Z2 | 15d | 2023-06-16 | 2023-07-06 | 32SS | 76d |  | 0 /día | 0 | 16/06/2023 - 06/07/2023 15d. | Sin Comenzar | 6.13 redes p4 Z2 |
| 113 | 6.14 | redes p5 Z2 | 15d | 2023-07-06 | 2023-07-26 | 34SS | 62d |  | 0 /día | 0 | 06/07/2023 - 26/07/2023 15d. | Sin Comenzar | 6.14 redes p5 Z2 |
| 114 | 6.15 | redes p6 Z2 | 15d | 2023-07-26 | 2023-08-15 | 36SS | 48d |  | 0 /día | 0 | 26/07/2023 - 15/08/2023 15d. | Sin Comenzar | 6.15 redes p6 Z2 |
| 115 | 6.16 | redes cubierta Z2 | 18d | 2023-08-15 | 2023-09-07 | 38SS | 31d | 0d | 0 /día | 0 | 15/08/2023 - 07/09/2023 18d. | Sin Comenzar | 6.16 redes cubierta Z2 |
| 116 | 6.17 | redes caseton Z2 | 6d | 2023-08-31 | 2023-09-07 | 115FF | 31d |  | 0 /día | 0 | 31/08/2023 - 07/09/2023 6d. | Sin Comenzar | 6.17 redes caseton Z2 |

| ID | WBS | Task | Duration | Start | Finish | Predecessors | Total slack | Free slack | Rdto. Minorado | Med. Ejec. | Planif. | Real | EDT y Nombre |
| --- | --- | --- | --- | --- | --- | --- | --- | --- | --- | --- | --- | --- | --- |
| 117 | 7 | **Seguridad zona 3** | 105d | 2023-05-08 | 2023-09-29 |  | 15d |  | 0 /día | 0 | 18/09/2023 - 18/09/2023 1d. | Sin Comenzar | 7 Seguridad zona 3 |
| 118 | 7.1 | barandillas planta baja Z3 | 1d | 2023-05-08 | 2023-05-08 | 44 | 119d |  | 0 /día | 0 | 08/05/2023 - 08/05/2023 1d. | Sin Comenzar | 7.1 barandillas planta baja Z3 |
| 119 | 7.2 | barandillas p1 Z3 | 1d | 2023-05-26 | 2023-05-26 | 46 | 105d |  | 0 /día | 0 | 26/05/2023 - 26/05/2023 1d. | Sin Comenzar | 7.2 barandillas p1 Z3 |
| 120 | 7.3 | barandillas p2 Z3 | 1d | 2023-06-15 | 2023-06-15 | 48 | 91d |  | 0 /día | 0 | 15/06/2023 - 15/06/2023 1d. | Sin Comenzar | 7.3 barandillas p2 Z3 |
| 121 | 7.4 | barandillas p3 Z3 | 1d | 2023-07-05 | 2023-07-05 | 50 | 77d |  | 0 /día | 0 | 05/07/2023 - 05/07/2023 1d. | Sin Comenzar | 7.4 barandillas p3 Z3 |
| 122 | 7.5 | barandillas p4 Z3 | 1d | 2023-07-25 | 2023-07-25 | 52 | 63d |  | 0 /día | 0 | 25/07/2023 - 25/07/2023 1d. | Sin Comenzar | 7.5 barandillas p4 Z3 |
| 123 | 7.6 | barandillas p5 Z3 | 1d | 2023-08-14 | 2023-08-14 | 54 | 49d |  | 0 /día | 0 | 14/08/2023 - 14/08/2023 1d. | Sin Comenzar | 7.6 barandillas p5 Z3 |
| 124 | 7.7 | barandillas p6 Z3 | 1d | 2023-09-01 | 2023-09-01 | 56 | 35d |  | 0 /día | 0 | 01/09/2023 - 01/09/2023 1d. | Sin Comenzar | 7.7 barandillas p6 Z3 |
| 125 | 7.8 | barandillas cubierta Z3 | 1d | 2023-09-21 | 2023-09-21 | 58 | 21d |  | 0 /día | 0 | 21/09/2023 - 21/09/2023 1d. | Sin Comenzar | 7.8 barandillas cubierta Z3 |
| 126 | 7.9 | barandillas caseton Z3 | 1d | 2023-09-29 | 2023-09-29 | 60 | 15d |  | 0 /día | 0 | 29/09/2023 - 29/09/2023 1d. | Sin Comenzar | 7.9 barandillas caseton Z3 |
| 127 | 7.10 | redes p1 Z3 | 15d | 2023-05-10 | 2023-05-30 | 46SS | 103d |  | 0 /día | 0 | 10/05/2023 - 30/05/2023 15d. | Sin Comenzar | 7.10 redes p1 Z3 |
| 128 | 7.11 | redes p2 Z3 | 15d | 2023-05-30 | 2023-06-19 | 48SS | 89d |  | 0 /día | 0 | 30/05/2023 - 19/06/2023 15d. | Sin Comenzar | 7.11 redes p2 Z3 |
| 129 | 7.12 | redes p3 Z3 | 15d | 2023-06-19 | 2023-07-07 | 50SS | 75d |  | 0 /día | 0 | 19/06/2023 - 07/07/2023 15d. | Sin Comenzar | 7.12 redes p3 Z3 |
| 130 | 7.13 | redes p4 Z3 | 15d | 2023-07-07 | 2023-07-27 | 52SS | 61d |  | 0 /día | 0 | 07/07/2023 - 27/07/2023 15d. | Sin Comenzar | 7.13 redes p4 Z3 |
| 131 | 7.14 | redes p5 Z3 | 15d | 2023-07-27 | 2023-08-16 | 54SS | 47d |  | 0 /día | 0 | 27/07/2023 - 16/08/2023 15d. | Sin Comenzar | 7.14 redes p5 Z3 |
| 132 | 7.15 | redes p6 Z3 | 15d | 2023-08-16 | 2023-09-05 | 56SS | 33d |  | 0 /día | 0 | 16/08/2023 - 05/09/2023 15d. | Sin Comenzar | 7.15 redes p6 Z3 |
| 133 | 7.16 | redes cubierta Z3 | 18d | 2023-09-05 | 2023-09-28 | 58SS | 16d | 0d | 0 /día | 0 | 05/09/2023 - 28/09/2023 18d. | Sin Comenzar | 7.16 redes cubierta Z3 |
| 134 | 7.17 | redes caseton Z3 | 6d | 2023-09-21 | 2023-09-28 | 133FF | 16d |  | 0 /día | 0 | 21/09/2023 - 28/09/2023 6d. | Sin Comenzar | 7.17 redes caseton Z3 |
| 135 | 8 | **Seguridad zona 4** | 105d | 2023-05-29 | 2023-10-20 |  | 0d |  |  |  |  |  | 8 Seguridad zona 4 |
| 136 | 8.1 | barandillas planta baja Z4 | 1d | 2023-05-29 | 2023-05-29 | 64 | 104d |  | 0 /día | 0 | 29/05/2023 - 29/05/2023 1d. | Sin Comenzar | 8.1 barandillas planta baja Z4 |
| 137 | 8.2 | barandillas p1 Z4 | 1d | 2023-06-16 | 2023-06-16 | 66 | 90d |  | 0 /día | 0 | 16/06/2023 - 16/06/2023 1d. | Sin Comenzar | 8.2 barandillas p1 Z4 |
| 138 | 8.3 | barandillas p2 Z4 | 1d | 2023-07-06 | 2023-07-06 | 68 | 76d |  | 0 /día | 0 | 06/07/2023 - 06/07/2023 1d. | Sin Comenzar | 8.3 barandillas p2 Z4 |
| 139 | 8.4 | barandillas p3 Z4 | 1d | 2023-07-26 | 2023-07-26 | 70 | 62d |  | 0 /día | 0 | 26/07/2023 - 26/07/2023 1d. | Sin Comenzar | 8.4 barandillas p3 Z4 |
| 140 | 8.5 | barandillas p4 Z4 | 1d | 2023-08-15 | 2023-08-15 | 72 | 48d |  | 0 /día | 0 | 15/08/2023 - 15/08/2023 1d. | Sin Comenzar | 8.5 barandillas p4 Z4 |
| 141 | 8.6 | barandillas p5 Z4 | 1d | 2023-09-04 | 2023-09-04 | 74 | 34d |  | 0 /día | 0 | 04/09/2023 - 04/09/2023 1d. | Sin Comenzar | 8.6 barandillas p5 Z4 |
| 142 | 8.7 | barandillas p6 Z4 | 1d | 2023-09-22 | 2023-09-22 | 76 | 20d |  | 0 /día | 0 | 22/09/2023 - 22/09/2023 1d. | Sin Comenzar | 8.7 barandillas p6 Z4 |
| 143 | 8.8 | barandillas cubierta Z4 | 1d | 2023-10-12 | 2023-10-12 | 78 | 6d |  | 0 /día | 0 | 12/10/2023 - 12/10/2023 1d. | Sin Comenzar | 8.8 barandillas cubierta Z4 |
| 144 | 8.9 | barandillas caseton Z4 | 1d | 2023-10-20 | 2023-10-20 | 80 | 0d |  | 0 /día | 0 | 20/10/2023 - 20/10/2023 1d. | Sin Comenzar | 8.9 barandillas caseton Z4 |
| 145 | 8.10 | redes p1 Z4 | 15d | 2023-05-31 | 2023-06-20 | 66SS | 88d |  | 0 /día | 0 | 31/05/2023 - 20/06/2023 15d. | Sin Comenzar | 8.10 redes p1 Z4 |
| 146 | 8.11 | redes p2 Z4 | 15d | 2023-06-20 | 2023-07-10 | 68SS | 74d |  | 0 /día | 0 | 20/06/2023 - 10/07/2023 15d. | Sin Comenzar | 8.11 redes p2 Z4 |
| 147 | 8.12 | redes p3 Z4 | 15d | 2023-07-10 | 2023-07-28 | 70SS | 60d |  | 0 /día | 0 | 10/07/2023 - 28/07/2023 15d. | Sin Comenzar | 8.12 redes p3 Z4 |
| 148 | 8.13 | redes p4 Z4 | 15d | 2023-07-28 | 2023-08-17 | 72SS | 46d |  | 0 /día | 0 | 28/07/2023 - 17/08/2023 15d. | Sin Comenzar | 8.13 redes p4 Z4 |
| 149 | 8.14 | redes p5 Z4 | 15d | 2023-08-17 | 2023-09-06 | 74SS | 32d |  | 0 /día | 0 | 17/08/2023 - 06/09/2023 15d. | Sin Comenzar | 8.14 redes p5 Z4 |
| 150 | 8.15 | redes p6 Z4 | 15d | 2023-09-06 | 2023-09-26 | 76SS | 18d |  | 0 /día | 0 | 06/09/2023 - 26/09/2023 15d. | Sin Comenzar | 8.15 redes p6 Z4 |
| 151 | 8.16 | redes cubierta Z4 | 18d | 2023-09-26 | 2023-10-19 | 78SS | 1d | 0d | 0 /día | 0 | 26/09/2023 - 19/10/2023 18d. | Sin Comenzar | 8.16 redes cubierta Z4 |
| 152 | 8.17 | redes caseton Z4 | 6d | 2023-10-12 | 2023-10-19 | 151FF | 1d |  | 0 /día | 0 | 12/10/2023 - 19/10/2023 6d. | Sin Comenzar | 8.17 redes caseton Z4 |
